# Moneta Fase 2 - Etapa 1 y 2 V2

Schedule from MS Project, 2017-11-15 to 2018-03-14, A marks actual dates.

## Calendars

- Estándar: Mon-Fri 09:00-13:00, 15:00-19:00; Sat-Sun off.

## Schedule

| ID | WBS | Task | Type | Duration | Start | Finish | Complete | Remaining | Total slack |
| --- | --- | --- | --- | --- | --- | --- | --- | --- | --- |
| 1 | 1 | **Moneta Fase II** |  | 86d | 2017-11-15 A | 2018-03-14 | 53% | 40.34d | 0d |
| 2 | 1.1 | **Etapa 1** |  | 37d | 2017-11-15 A | 2018-01-04 A | 100% |  |  |
| 3 | 1.1.1 | **Planificación** |  | 15d | 2017-11-15 A | 2017-12-05 A | 100% |  |  |
| 4 | 1.1.1.1 | Definición de Alcance | manual | 5d | 2017-11-15 A | 2017-11-21 A | 100% |  |  |
| 5 | 1.1.1.2 | Definición de IVR | manual | 14d | 2017-11-15 A | 2017-12-04 A | 100% |  |  |
| 6 | 1.1.1.3 | Envío de Alcance a Proveedor | manual | 1d | 2017-11-22 A | 2017-11-22 A | 100% |  |  |
| 7 | 1.1.1.4 | Gestion de Servidores | manual | 5d | 2017-11-27 A | 2017-12-01 A | 100% |  |  |
| 8 | 1.1.1.5 | Creación de Politica | manual | 4d | 2017-11-30 A | 2017-12-05 A | 100% |  |  |
| 9 | 1.1.1.6 | Generación de Cronograma | manual | 1d | 2017-12-05 A | 2017-12-05 A | 100% |  |  |
| 10 | 1.1.2 | **Ejecución** |  | 24d | 2017-12-04 A | 2018-01-04 A | 100% |  |  |
| 11 | 1.1.2.1 | Desarrollo | manual | 7d | 2017-12-04 A | 2017-12-12 A | 100% |  |  |
| 12 | 1.1.2.2 | Certificación | manual | 1d | 2017-12-13 A | 2017-12-13 A | 100% |  |  |
| 13 | 1.1.2.3 | Corrección de Observaciones | manual | 9d | 2017-12-14 A | 2017-12-27 A | 100% |  |  |
| 14 | 1.1.2.4 | Retest de Certificación | manual | 2d | 2018-01-03 A | 2018-01-04 A | 100% |  |  |
| 15 | 1.2 | **Etapa 2** |  | 68d | 2017-12-11 A | 2018-03-14 | 36% | 43.2d | 0d |
| 16 | 1.2.1 | **Planificación** |  | 28d | 2017-12-11 A | 2018-01-17 | 78% | 6.08d | 0d |
| 17 | 1.2.1.1 | Gestion de SMS con Proveedor INTICO y Redes UPC | manual | 25d | 2017-12-12 A | 2018-01-15 | 70% | 7.5d |  |
| 18 | 1.2.1.2 | Gestion de envío de contraseña por correo | manual | 25d | 2017-12-11 A | 2018-01-12 A | 100% |  |  |
| 19 | 1.2.1.3 | Envío de Datos de configuracion de SMS a proveedor | manual | 4d | 2018-01-10 A | 2018-01-15 |  | 4d |  |
| 20 | 1.2.1.4 | Envío de Datos de configuración de Correo a proveedor | manual | 3d | 2018-01-03 A | 2018-01-05 A | 100% |  |  |
| 21 | 1.2.1.5 | Creación de Politica | manual | 3d | 2018-01-15 A | 2018-01-17 | 20% | 2.4d |  |
| 22 | 1.2.1.6 | Generación de Cronograma | manual | 2d | 2018-01-02 A | 2018-01-03 A | 100% |  |  |
| 23 | 1.2.1.7 | Envío de nombres de servidores e Ips de producción | manual | 1d | 2018-01-15 A | 2018-01-15 A | 100% |  |  |
| 24 | 1.2.1.8 | Enviar Datos Actualizados | manual | 1d | 2018-01-15 A | 2018-01-15 A | 100% |  |  |

| ID | WBS | Task | Type | Duration | Start | Finish | Complete | Remaining | Total slack |
| --- | --- | --- | --- | --- | --- | --- | --- | --- | --- |
| 25 | 1.2.2 | **Ejecución** |  | 17d | 2018-01-09 A | 2018-01-31 | 1% | 16.84d | 0d |
| 26 | 1.2.2.1 | Actualizar Project con fecha fin de cara actividad | manual | 3h | 2018-01-09 A | 2018-01-09 A | 100% |  |  |
| 27 | 1.2.2.2 | Cambio de contraseña por correo | manual | 2d | 2018-01-17 | 2018-01-18 |  |  |  |
| 28 | 1.2.2.3 | Cambio de contraseña por SMS | manual | 2d | 2018-01-17 | 2018-01-18 |  |  |  |
| 29 | 1.2.2.4 | Administración de tipo de envío de contraseñas por tipo de usuario | manual | 5d | 2018-01-15 | 2018-01-19 |  |  |  |
| 30 | 1.2.2.5 | Replicador de la Información de Moneta | manual | 4d | 2018-01-16 | 2018-01-19 |  |  |  |
| 31 | 1.2.2.6 | Gestión de Datos de Moneta | manual | 5d | 2018-01-22 | 2018-01-26 |  |  |  |
| 32 | 1.2.2.7 | Log de Transacciones | manual | 5d | 2018-01-22 | 2018-01-26 |  |  |  |
| 33 | 1.2.2.8 | Reportes | manual | 5d | 2018-01-22 | 2018-01-26 |  |  |  |
| 34 | 1.2.2.9 | **Corrección de Observaciones** |  | 3d | 2018-01-12 | 2018-01-16 |  |  |  |
| 35 | 1.2.2.9.1 | Aumentar volumen de letras y números en dictado de contraseña | manual | 1d | 2018-01-12 | 2018-01-12 |  |  |  |
| 36 | 1.2.2.9.2 | Corrección de Datos de la Base de Datos | manual | 1d | 2018-01-13 | 2018-01-13 |  |  |  |
| 37 | 1.2.2.9.3 | Cargar de Datos Actualizados en la Base de Datos | manual | 1d | 2018-01-15 | 2018-01-15 |  |  |  |
| 38 | 1.2.2.10 | **Actualizar Configuracion** |  | 1d | 2018-01-29 | 2018-01-29 |  |  |  |
| 39 | 1.2.2.10.1 | Certificación | manual | 1d | 2018-01-29 | 2018-01-29 |  |  |  |
| 40 | 1.2.2.11 | Creación de Casos de Prueba | manual | 2d | 2018-01-22 | 2018-01-23 |  |  |  |
| 41 | 1.2.2.12 | Ejecución de Pruebas | manual | 2d | 2018-01-29 | 2018-01-30 |  |  |  |
| 42 | 1.2.2.13 | Envío de Informe de certificación | manual | 1d | 2018-01-29 | 2018-01-29 |  |  |  |
| 43 | 1.2.2.14 | Corrección de Observaciones | manual | 1d | 2018-01-30 | 2018-01-30 |  |  |  |
| 44 | 1.2.2.15 | Retest | manual | 1d | 2018-01-31 | 2018-01-31 |  |  |  |
| 45 | 1.2.3 | **Pase a Producción** |  | 4d | 2018-01-29 | 2018-02-01 |  |  |  |
| 46 | 1.2.3.1 | Configuración de servidores de producción (CLUSTER) | manual | 1d | 2018-01-29 | 2018-01-29 |  |  |  |
| 47 | 1.2.3.2 | Instalacion de Software Moneta II | manual | 1d | 2018-01-30 | 2018-01-30 |  |  |  |
| 48 | 1.2.3.3 | Migración de Datos | manual | 1d | 2018-01-31 | 2018-01-31 |  |  |  |
| 49 | 1.2.3.4 | Configuración de Centrál Telefónica | manual | 1d | 2018-01-31 | 2018-01-31 |  |  |  |
| 50 | 1.2.3.5 | Pruebas de Produccion | manual | 1d | 2018-02-01 | 2018-02-01 |  |  |  |
| 51 | 1.2.4 | Marcha Blanca | manual | 30d | 2018-02-01 | 2018-03-14 |  |  |  |
